# GANTT NUEVO JERUSALEM ALTERNATIVO

Schedule from MS Project, 2020-11-02 to 2021-04-30, costs in S/..

## Calendars

- Estándar: Mon-Sun 09:00-13:00, 15:00-19:00.

## Schedule

| ID | WBS | Task | Duration | Start | Finish | Predecessors | Total slack | Free slack | Cost |
| --- | --- | --- | --- | --- | --- | --- | --- | --- | --- |
| 1 | 1 | **“RECUPERACIÓN DEL LOCAL ESCOLAR I.E. N° 1762 – SAGRADO CORAZÓN DE JESÚS CON CÓDIGO LOCAL 253846 DEL DISTRITO DE LA ESPERANZA – TRUJILLO – LA LIBERTAD”** | 180d | 2020-11-02 | 2021-04-30 |  |  |  | 965,589.02 |
| 2 | 1.1 | **OBRAS PROVICIONALES, TRABAJOS PRELIMINARES, SEGURIDAD Y SALUD** | 180d | 2020-11-02 | 2021-04-30 |  | 0d |  | 95,510.73 |
| 3 | 1.1.1 | **OBRAS PROVISIONALES Y TRABAJOS PRELIMINARES** | 180d | 2020-11-02 | 2021-04-30 |  | 0d |  | 14,548.23 |
| 4 | 1.1.1.1 | CARTEL DE IDENTIFICACION DE OBRA DE 3.60X7.20 mts | 1d | 2020-11-02 | 2020-11-02 | 5SS | 0d |  | 1,497.13 |
| 5 | 1.1.1.2 | ALMACEN, OFICINA Y CASETA DE GUARDIANIA | 2d | 2020-11-02 | 2020-11-03 |  | 0d |  | 2,000 |
| 6 | 1.1.1.3 | CERCO PROVISIONAL (MAD C/TRIPLAY) | 2d | 2020-11-02 | 2020-11-03 | 5SS | 178d |  | 5,638.49 |
| 7 | 1.1.1.4 | MOVILIZACION Y DESMOVILIZACION | 3d | 2020-11-02 | 2020-11-04 | 5SS | 177d |  | 2,412.61 |
| 8 | 1.1.1.5 | AGUA Y DESAGUE PARA LA CONSTRUCCIÓN | 179d | 2020-11-03 | 2021-04-30 | 4 | 0d |  | 1,500 |
| 9 | 1.1.1.6 | ENERGIA ELECTRICA PROVISIONAL | 179d | 2020-11-03 | 2021-04-30 | 4 | 0d |  | 1,500 |
| 10 | 1.1.2 | **OBRAS PRELIMINARES** | 179d | 2020-11-03 | 2021-04-30 |  | 0d |  | 51,139.56 |
| 11 | 1.1.2.1 | LIMPIEZA DE TERRENO | 2d | 2020-11-11 | 2020-11-12 | 22 | 63d | 0d | 6,342.26 |
| 12 | 1.1.2.2 | TRAZO Y REPLATEO | 4d | 2020-11-12 | 2020-11-15 | 11FS-1d | 63d | 0d | 3,372.47 |
| 13 | 1.1.2.3 | DESMONTAJE DE COBERTURA DE PLANCHAS DE ETERNIT | 1d | 2020-11-03 | 2020-11-03 | 16SS | 178d |  | 1,723.44 |
| 14 | 1.1.2.4 | DESMONTAJE DE PUERTAS DE MADERA | 1d | 2020-11-03 | 2020-11-03 | 8SS | 63d | 0d | 284.02 |
| 15 | 1.1.2.5 | DESMONTAJE DE PUERTAS DE FIERRO | 1d | 2020-11-03 | 2020-11-03 | 14SS | 63d | 0d | 33.92 |
| 16 | 1.1.2.6 | DESMONTAJE DE VENTANAS DE FIERRO | 1d | 2020-11-03 | 2020-11-03 | 15SS | 63d | 0d | 51.6 |
| 17 | 1.1.2.7 | DEMOLICION DE MURO DE ALBAÑILERIA CON MAQUINARIA | 3d | 2020-11-04 | 2020-11-06 | 16 | 63d | 0d | 14,890.23 |
| 18 | 1.1.2.8 | DEMOLICION DE PISO INCLUIDO FALSO PISO | 1d | 2020-11-09 | 2020-11-09 | 21 | 172d |  | 1,624.22 |
| 19 | 1.1.2.9 | DEMOLICION DE VEREDAS DE 0.10 | 1d | 2020-11-07 | 2020-11-07 | 17 | 174d |  | 364.16 |
| 20 | 1.1.2.10 | DEMOLICION DE COLUMNAS DE CONCRETO ARMADO | 1d | 2020-11-07 | 2020-11-07 | 17 | 63d | 0d | 1,379.81 |
| 21 | 1.1.2.11 | DEMOLICION DE SOBRECIMIENTOS DE CONCRETO SIMPLE | 1d | 2020-11-08 | 2020-11-08 | 20 | 63d | 0d | 2,744.68 |
| 22 | 1.1.2.12 | DEMOLICION DE CIMIENTOS DE CONCRETO SIMPLE | 2d | 2020-11-09 | 2020-11-10 | 21 | 63d | 0d | 7,030 |
| 23 | 1.1.2.13 | ELIMINACION DE MATERIAL EXCEDENTE CON EQUIPO HASTA 15 km | 1d | 2020-11-07 | 2020-11-07 | 17 | 174d |  | 4,923.75 |
| 24 | 1.1.2.14 | SEÑALIZACION Y SEGURIDAD PARA LA OBRA | 179d | 2020-11-03 | 2021-04-30 | 4 | 0d |  | 1,510 |
| 25 | 1.1.2.15 | EQUIPOS DE PROTECCION INDIVIDUAL | 179d | 2020-11-03 | 2021-04-30 | 4 | 0d |  | 1,815 |
| 26 | 1.1.2.16 | EQUIPOS DE PROTECCION COLECTIVA | 179d | 2020-11-03 | 2021-04-30 | 4 | 0d |  | 800 |
| 27 | 1.1.2.17 | SERVICIOS HIGIENICOS DE OBRA (CONTENEDORES) | 179d | 2020-11-03 | 2021-04-30 | 4 | 0d |  | 2,250 |

| ID | WBS | Task | Duration | Start | Finish | Predecessors | Total slack | Free slack | Cost |
| --- | --- | --- | --- | --- | --- | --- | --- | --- | --- |
| 28 | 1.1.3 | **PLAN PARA LA VIGILANCIA, PREVENCIÓN Y CONTROL DE LA COVID-19 EN EL TRABAJO** | 179d | 2020-11-03 | 2021-04-30 |  | 0d |  | 29,822.94 |
| 29 | 1.1.3.1 | **PROGRAMA DE MONITOREO Y/O PREVENCIÓN** | 179d | 2020-11-03 | 2021-04-30 |  | 0d |  | 9,570 |
| 30 | 1.1.3.1.1 | MATERIALES Y/O EQUIPO | 179d | 2020-11-03 | 2021-04-30 | 4 | 0d |  | 1,200 |
| 31 | 1.1.3.1.2 | CONTINGENCIAS Y EMERGENCIAS | 179d | 2020-11-03 | 2021-04-30 | 4 | 0d |  | 8,370 |
| 32 | 1.1.3.2 | **PROGRAMA DE MEDIDAS PREVENTIVAS Y/O CORRECTIVAS** | 179d | 2020-11-03 | 2021-04-30 |  | 0d |  | 13,193.94 |
| 33 | 1.1.3.2.1 | PROTECCIÓN COLECTIVA / AREA DE DESINFECCION | 179d | 2020-11-03 | 2021-04-30 | 4 | 0d |  | 5,797.44 |
| 34 | 1.1.3.2.2 | USO DE EQUIPO PROTECCIÓN PERSONAL | 179d | 2020-11-03 | 2021-04-30 | 4 | 0d |  | 7,396.5 |
| 35 | 1.1.3.3 | **PROGRAMA DE SEÑALIZACION EN SEGURIDAD Y PROTECCION AMBIENTAL** | 1d | 2020-11-03 | 2020-11-03 |  | 178d |  | 959 |
| 36 | 1.1.3.3.1 | SEÑALETICA DE TRIPLAY CON VINIL ADHESIVO (IMPERMEABLE Y RESISTENTE) DE 100 CM. X 60 CM. | 1d | 2020-11-03 | 2020-11-03 | 4 | 178d |  | 224 |
| 37 | 1.1.3.3.2 | SEÑALETICA DE TRIPLAY CON VINIL ADHESIVO (IMPERMEABLE Y RESISTENTE) DE 100 CM. X 60 CM. | 1d | 2020-11-03 | 2020-11-03 | 4 | 178d |  | 735 |
| 38 | 1.1.3.4 | **PROGRAMA DE MANEJO DE LOS RESIDUOS SOLIDOS** | 179d | 2020-11-03 | 2021-04-30 |  | 0d |  | 6,100 |
| 39 | 1.1.3.4.1 | GESTIÓN DE RESIDUOS SÓLIDOS COMUNES | 179d | 2020-11-03 | 2021-04-30 | 4 | 0d |  | 3,050 |
| 40 | 1.1.3.4.2 | GESTIÓN DE RESIDUOS SÓLIDOS PELIGROSOS | 179d | 2020-11-03 | 2021-04-30 | 4 | 0d |  | 3,050 |
| 41 | 1.2 | **MOVIMIENTO DE TIERRAS** | 52d | 2020-11-15 | 2021-01-05 |  | 63d |  | 37,835.08 |
| 42 | 1.2.1 | EXCAVACION P/CIMIENTOS, ZAPATAS Y VIGAS DE CIMENTACION | 20d | 2020-11-15 | 2020-12-04 | 12FS-1d | 63d | 0d | 15,487.58 |
| 43 | 1.2.2 | RELLENO COMPACTADO C/EQUIPO MAT/AFIRMADO | 6d | 2020-12-17 | 2020-12-22 | 60FS+2d | 115d | 0d | 6,782.05 |
| 44 | 1.2.3 | NIVELACION Y APISONADO | 7d | 2020-12-23 | 2020-12-29 | 43 | 115d | 0d | 1,495.67 |
| 45 | 1.2.4 | BASE DE AFIRMADO, E=0.10 M, P/PISOS, VEREDAS Y PATIOS | 7d | 2020-12-30 | 2021-01-05 | 44 | 115d |  | 6,879.05 |
| 46 | 1.2.5 | ACARREO DE MATERIAL | 14d | 2020-12-23 | 2021-01-05 | 43 | 115d |  | 7,190.73 |
| 47 | 1.3 | **CONCRETO SIMPLE** | 47d | 2020-11-20 | 2021-01-05 |  | 63d |  | 62,093.12 |
| 48 | 1.3.1 | **FALSA ZAPATA** | 6d | 2020-11-20 | 2020-11-25 |  | 63d |  | 9,131.04 |
| 49 | 1.3.1.1 | FALSA ZAPATA f'c=100 kg/cm2 + 25% P.G. | 6d | 2020-11-20 | 2020-11-25 | 42SS+5d | 63d | 0d | 9,131.04 |
| 50 | 1.3.2 | **FALSO CIMIENTO** | 4d | 2020-11-23 | 2020-11-26 |  | 155d |  | 2,050.06 |
| 51 | 1.3.2.1 | FALSO CIMIENTO f'c=100 kg/cm2 + 25% P.G. | 4d | 2020-11-23 | 2020-11-26 | 49FS-3d | 155d |  | 2,050.06 |

| ID | WBS | Task | Duration | Start | Finish | Predecessors | Total slack | Free slack | Cost |
| --- | --- | --- | --- | --- | --- | --- | --- | --- | --- |
| 52 | 1.3.3 | **SOLADOS** | 1d | 2020-11-26 | 2020-11-26 |  | 63d |  | 3,295.49 |
| 53 | 1.3.3.1 | SOLADO 1:10, CEMENTO:HORMIGON E=4" | 1d | 2020-11-26 | 2020-11-26 | 49 | 63d | 0d | 3,295.49 |
| 54 | 1.3.4 | **CIMIENTOS-SOBRECIMIENTO** | 40d | 2020-11-27 | 2021-01-05 |  | 63d |  | 47,616.53 |
| 55 | 1.3.4.1 | CONCRETO 1:10 +30% P.G. PARA CIMIENTOS CORRIDOS | 2d | 2020-11-30 | 2020-12-01 | 56 | 150d |  | 22,109.38 |
| 56 | 1.3.4.2 | ENCOFRADO Y DESENCOFRADO NORMAL PARA SOBRECIMIENTO HASTA 0.30 m | 3d | 2020-11-27 | 2020-11-29 | 53 | 63d | 0d | 2,797.99 |
| 57 | 1.3.4.3 | CONCRETO EN FALSO PISO 4"(C:A:PCH) 1:3:5:4:5 | 7d | 2020-12-30 | 2021-01-05 | 44 | 115d |  | 22,709.16 |
| 58 | 1.4 | **CONCRETO ARMADO** | 49d | 2020-11-27 | 2021-01-14 |  | 75d |  | 272,792.98 |
| 59 | 1.4.1 | **ZAPATAS** | 18d | 2020-11-27 | 2020-12-14 |  | 115d |  | 30,374.26 |
| 60 | 1.4.1.1 | CONCRETO F'C= 210 KG/CM2 - ZAPATAS | 7d | 2020-12-08 | 2020-12-14 | 61FS+2d | 115d | 0d | 20,979.33 |
| 61 | 1.4.1.2 | ACERO DE REFUERZO FY= 4200 KG/CM2 - ZAPATAS | 9d | 2020-11-27 | 2020-12-05 | 53 | 115d | 0d | 9,394.93 |
| 62 | 1.4.2 | **SOBRECIMIENTO** | 5d | 2020-12-09 | 2020-12-13 |  | 63d |  | 30,921.06 |
| 63 | 1.4.2.1 | CONCRETO F'C= 210 KG/CM2 - SOBRECIMIENTO | 1d | 2020-12-13 | 2020-12-13 | 64 | 63d | 0d | 9,660.07 |
| 64 | 1.4.2.2 | ENCOFRADO Y DESENCOFRADO NORMAL - SOBRECIMIENTO | 3d | 2020-12-10 | 2020-12-12 | 65FS-1d | 63d | 0d | 14,037.75 |
| 65 | 1.4.2.3 | ACERO DE REFUERZO FY= 4200 KG/CM2 - SOBRECIMIENTO | 2d | 2020-12-09 | 2020-12-10 | 56FS+9d | 63d | 0d | 7,223.24 |
| 66 | 1.4.3 | **COLUMNAS** | 27d | 2020-12-14 | 2021-01-09 |  | 111d |  | 75,787.32 |
| 67 | 1.4.3.1 | CONCRETO F'C= 210 KG/CM2 - COLUMNAS | 5d | 2021-01-05 | 2021-01-09 | 68 | 111d | 0d | 15,307.04 |
| 68 | 1.4.3.2 | ENCOFRADO Y DESENCOFRADO NORMAL - COLUMNAS | 12d | 2020-12-24 | 2021-01-04 | 89 | 111d | 0d | 21,889 |
| 69 | 1.4.3.3 | ACERO DE REFUERZO FY= 4200 KG/CM2 - COLUMNAS | 10d | 2020-12-14 | 2020-12-23 | 68SS-10d | 128d | 0d | 38,591.28 |
| 70 | 1.4.4 | **COLUMNETAS** | 21d | 2020-12-14 | 2021-01-03 |  | 73d |  | 20,470.08 |
| 71 | 1.4.4.1 | CONCRETO F'C= 175 KG/CM2 - COLUMNETAS | 1d | 2021-01-03 | 2021-01-03 | 72 | 63d | 0d | 4,037.55 |
| 72 | 1.4.4.2 | ENCOFRADO Y DESENCOFRADO NORMAL - COLUMNETAS | 10d | 2020-12-24 | 2021-01-02 | 89 | 63d | 0d | 8,010.41 |
| 73 | 1.4.4.3 | ACERO DE REFUERZO FY= 4200 KG/CM2 - COLUMNETAS | 10d | 2020-12-14 | 2020-12-23 | 72SS-10d | 128d |  | 8,422.12 |
| 74 | 1.4.5 | **VIGAS** | 20d | 2020-12-26 | 2021-01-14 |  | 71d |  | 55,440.07 |
| 75 | 1.4.5.1 | CONCRETO F'C= 210 KG/CM2 - VIGAS | 2d | 2021-01-13 | 2021-01-14 | 76 | 106d | 0d | 15,210.63 |
| 76 | 1.4.5.2 | ENCOFRADO Y DESENCOFRADO NORMAL - VIGAS | 10d | 2021-01-03 | 2021-01-12 | 71FS-1d | 63d | 0d | 18,437.69 |
| 77 | 1.4.5.3 | ACERO DE REFUERZO FY= 4200 KG/CM2 - VIGAS | 7d | 2020-12-26 | 2021-01-01 | 76SS-8d | 119d | 0d | 21,791.75 |

| ID | WBS | Task | Duration | Start | Finish | Predecessors | Total slack | Free slack | Cost |
| --- | --- | --- | --- | --- | --- | --- | --- | --- | --- |
| 78 | 1.4.6 | **VIGA DE CONFINAMIENTO** | 19d | 2020-12-26 | 2021-01-13 |  | 107d |  | 5,336.61 |
| 79 | 1.4.6.1 | CONCRETO F'C= 175 KG/CM2 - VIGA DE CONFINAMIENTO | 1d | 2021-01-13 | 2021-01-13 | 80 | 107d |  | 1,033.83 |
| 80 | 1.4.6.2 | ENCOFRADO Y DESENCOFRADO NORMAL - VIGAS DE CONFINAMIENTO | 10d | 2021-01-03 | 2021-01-12 | 71FS-1d | 107d | 0d | 1,950.59 |
| 81 | 1.4.6.3 | ACERO DE REFUERZO FY= 4200 KG/CM2 - VIGAS DE CONFINAMIENTO | 7d | 2020-12-26 | 2021-01-01 | 80SS-8d | 119d |  | 2,352.19 |
| 82 | 1.4.7 | **LOSA ALIGERADA** | 7d | 2021-01-08 | 2021-01-14 |  | 106d |  | 54,463.58 |
| 83 | 1.4.7.1 | CONCRETO F'C= 210 KG/CM2 - LOSA ALIGERADA | 1d | 2021-01-13 | 2021-01-13 | 86 | 107d | 0d | 13,811.75 |
| 84 | 1.4.7.2 | ENCOFRADO Y DESENCOFRADO NORMAL - LOSA ALIGERADA | 4d | 2021-01-08 | 2021-01-11 | 76SS+5d | 106d | 0d | 18,317.5 |
| 85 | 1.4.7.3 | LADRILLO HUECO DE ARCILLA 15x30x30 - LOSA ALIGERADA | 3d | 2021-01-12 | 2021-01-14 | 84 | 106d |  | 12,635.12 |
| 86 | 1.4.7.4 | ACERO DE REFUERZO FY= 4200 KG/CM2 - LOSA ALIGERADA | 1d | 2021-01-12 | 2021-01-12 | 84 | 107d | 0d | 9,699.21 |
| 87 | 1.5 | **ALBAÑILERIA** | 119d | 2020-11-03 | 2021-03-01 |  | 60d |  | 344,108.05 |
| 88 | 1.5.1 | **MUROS DE ALBAÑILERIA** | 33d | 2020-12-14 | 2021-01-15 |  | 63d |  | 55,236.76 |
| 89 | 1.5.1.1 | MURO DE LADRILLO KING KONG TIPO IV ASENTADO DE CABEZA CON MORTERO 1:5X1:5 CM | 10d | 2020-12-14 | 2020-12-23 | 63 | 63d | 0d | 7,572.8 |
| 90 | 1.5.1.2 | MURO DE LADRILLO KING KONG TIPO IV ASENTADO DE SOGA CON MORTERO 1:5X1:5 CM | 10d | 2021-01-06 | 2021-01-15 | 76SS+3d | 63d | 0d | 25,855.13 |
| 91 | 1.5.1.3 | MUROS DE LADRILLO LARK 18 HUECOS-ASENTADO CARAVISTA | 1d | 2021-01-06 | 2021-01-06 | 90SS | 114d |  | 21,808.83 |
| 92 | 1.5.2 | **REVOQUES Y ENLUCIDOS** | 17d | 2021-01-16 | 2021-02-01 |  | 63d |  | 57,759.18 |
| 93 | 1.5.2.1 | TARRAJEO PRIMARIO O RAYADO CON MORTERO C:A / 1:5 | 4d | 2021-01-16 | 2021-01-19 | 90 | 63d | 0d | 1,908.14 |
| 94 | 1.5.2.2 | TARRAJEO INTERIOR C/MORTERO 1:5 X 1:5 CM. | 12d | 2021-01-16 | 2021-01-27 | 93SS | 63d | 0d | 11,514.51 |
| 95 | 1.5.2.3 | TARRAJEO EXTERIOR C/MORTERO 1:5 X 1:5 CM. | 12d | 2021-01-16 | 2021-01-27 | 93SS | 93d | 0d | 18,951.03 |
| 96 | 1.5.2.4 | TARRAJEO DE COLUMNAS C/MORTERO 1:5 X 1:5 CM. | 6d | 2021-01-16 | 2021-01-21 | 94SS | 63d | 0d | 8,606.19 |
| 97 | 1.5.2.5 | TARRAJEO DE COLUMNAS DE AMARRE | 6d | 2021-01-16 | 2021-01-21 | 94SS | 99d |  | 2,496.4 |
| 98 | 1.5.2.6 | TARRAJEO DE VIGAS C/MORTERO 1:5 X 1:5 CM. | 7d | 2021-01-20 | 2021-01-26 | 96FS-2d | 63d | 0d | 10,121.11 |
| 99 | 1.5.2.7 | TARRAJEO DE VIGAS DE AMARRE | 7d | 2021-01-20 | 2021-01-26 | 98SS | 94d |  | 2,001.63 |
| 100 | 1.5.2.8 | VESTIDURA DE DERRAMES EN PUERTAS, VENTANAS Y VANOS | 6d | 2021-01-27 | 2021-02-01 | 103 | 80d | 0d | 841.22 |
| 101 | 1.5.2.9 | BRUÑAS EN PISO | 2d | 2021-01-16 | 2021-01-17 | 95SS | 103d |  | 1,318.95 |

| ID | WBS | Task | Duration | Start | Finish | Predecessors | Total slack | Free slack | Cost |
| --- | --- | --- | --- | --- | --- | --- | --- | --- | --- |
| 102 | 1.5.3 | **CIELORRASOS** | 7d | 2021-01-20 | 2021-01-26 |  | 63d |  | 17,684.82 |
| 103 | 1.5.3.1 | CIELORRASOS CON MEZCLA CEMENTO- ARENA MORTERO 1:4 | 7d | 2021-01-20 | 2021-01-26 | 98SS | 63d | 0d | 17,684.82 |
| 104 | 1.5.4 | **PISOS Y PAVIMENTOS** | 13d | 2021-01-25 | 2021-02-06 |  | 63d |  | 62,587.38 |
| 105 | 1.5.4.1 | VEREDAS Y RAMPAS DE CONCRETO DE 4" | 3d | 2021-02-02 | 2021-02-04 | 106SS | 85d |  | 6,777.14 |
| 106 | 1.5.4.2 | ENCOFRADO Y DESENCOFRADO DE VEREDAS Y RAMPAS | 5d | 2021-02-02 | 2021-02-06 | 100 | 80d | 0d | 1,022.73 |
| 107 | 1.5.4.3 | JUNTAS DE DILATACION RELLENO CON MORTERO ASFALTO E=1" | 5d | 2021-01-28 | 2021-02-01 | 108SS+3d | 88d |  | 83.38 |
| 108 | 1.5.4.4 | CONTRAPISOS E=40 mm | 1d | 2021-01-25 | 2021-01-25 | 103FS-2d | 63d | 0d | 10,537.86 |
| 109 | 1.5.4.5 | PISO CERAMICO ANTIDESLIZANTE 30x30 cm | 4d | 2021-01-26 | 2021-01-29 | 108 | 63d | 0d | 20,128 |
| 110 | 1.5.4.6 | COBERTURA LADRILLO PASTELERO ASENTADO C/MEZCLA | 3d | 2021-01-25 | 2021-01-27 | 108SS | 93d |  | 24,038.27 |
| 111 | 1.5.5 | **CUNETAS, SARDINELES DE CONCRETO SIMPLE** | 3d | 2021-02-02 | 2021-02-04 |  | 80d |  | 2,198.03 |
| 112 | 1.5.5.1 | CONCRETO EN CUNETA DE DRENAJE PLUVIAL, f'c=140 Kg/cm2 | 1d | 2021-02-04 | 2021-02-04 | 113 | 80d | 0d | 728.16 |
| 113 | 1.5.5.2 | ENCOFRADO Y DESENCOFRADO DE CUNETA DE DRENAJE | 1d | 2021-02-03 | 2021-02-03 | 114 | 80d | 0d | 413.97 |
| 114 | 1.5.5.3 | ACERO DE REFUERZO FY= 4200 KG/CM2 - CUNETA | 1d | 2021-02-02 | 2021-02-02 | 106SS | 80d | 0d | 259.56 |
| 115 | 1.5.5.4 | CONCRETO EN SARDINELES F'C=140 KG/CM2.. | 1d | 2021-02-04 | 2021-02-04 | 116 | 85d |  | 453.42 |
| 116 | 1.5.5.5 | ENCOFRADO Y DESENCOFRADO DE SARDINELES | 1d | 2021-02-03 | 2021-02-03 | 113SS | 85d | 0d | 342.92 |
| 117 | 1.5.6 | **ZOCALOS Y CONTRAZOCALOS** | 8d | 2021-01-30 | 2021-02-06 |  | 63d |  | 7,140.78 |
| 118 | 1.5.6.1 | CONTRAZOCALO DE CERAMICA DE COLOR H= 10 cm | 4d | 2021-01-30 | 2021-02-02 | 109 | 63d | 0d | 1,656.84 |
| 119 | 1.5.6.2 | ZOCALOS DE CERAMICA (20 X 30) | 3d | 2021-01-30 | 2021-02-01 | 109 | 88d |  | 4,361.52 |
| 120 | 1.5.6.3 | ZOCALO PULIDO A DE COLOR H=20 cm | 4d | 2021-02-03 | 2021-02-06 | 118 | 63d | 0d | 1,122.42 |
| 121 | 1.5.7 | **TECHOS Y CUBIERTAS** | 9d | 2021-01-25 | 2021-02-02 |  | 87d |  | 14,645.91 |
| 122 | 1.5.7.1 | ESTRUCTURA METALICA | 5d | 2021-01-25 | 2021-01-29 | 108SS | 87d | 0d | 2,630.58 |
| 123 | 1.5.7.2 | COBERTURA | 3d | 2021-01-30 | 2021-02-01 | 122 | 87d | 0d | 6,815.33 |
| 124 | 1.5.7.3 | EQUIPO COMPLEMENTARIO | 1d | 2021-02-02 | 2021-02-02 | 123 | 87d |  | 5,200 |
| 125 | 1.5.8 | **CARPINTERIA DE MADERA** | 4d | 2021-02-07 | 2021-02-10 |  | 63d |  | 6,485.7 |
| 126 | 1.5.8.1 | PUERTA TABLERO DE CEDRO CON FRESQUILLO | 3d | 2021-02-07 | 2021-02-09 | 120 | 63d | 0d | 5,340.36 |
| 127 | 1.5.8.2 | PUERTA DE MELAMINE E=18 mm | 1d | 2021-02-10 | 2021-02-10 | 126 | 78d | 0d | 1,145.34 |

| ID | WBS | Task | Duration | Start | Finish | Predecessors | Total slack | Free slack | Cost |
| --- | --- | --- | --- | --- | --- | --- | --- | --- | --- |
| 128 | 1.5.9 | **CARPINTERIA METALICA** | 12d | 2021-01-30 | 2021-02-10 |  | 79d |  | 33,393.63 |
| 129 | 1.5.9.1 | VENTANAS METALICAS | 1d | 2021-02-10 | 2021-02-10 | 126 | 78d | 0d | 29,640 |
| 130 | 1.5.9.2 | REJILLA SOBRE CUNETA PLUVIAL | 1d | 2021-02-04 | 2021-02-04 | 113 | 85d |  | 2,938.59 |
| 131 | 1.5.9.3 | PORTON METALICO INGRESO 1 DE 2.93*2.70 (doble hona-inc.cerrageria y pintado dos manos) | 1d | 2021-01-30 | 2021-01-30 | 109 | 90d |  | 815.04 |
| 132 | 1.5.10 | **CERRAJERIA** | 3d | 2021-02-10 | 2021-02-12 |  | 77d |  | 2,646.08 |
| 133 | 1.5.10.1 | CERRADURA PARA PUERTAS SECUNDARIAS | 1d | 2021-02-10 | 2021-02-10 | 126 | 77d | 0d | 1,154.04 |
| 134 | 1.5.10.2 | CERRADURA DE PERILLA DE EMBUTIR | 1d | 2021-02-11 | 2021-02-11 | 127 | 78d |  | 764.24 |
| 135 | 1.5.10.3 | BISAGRA CAPUCHINA DE 4"X 4" P/PUERTAS | 1d | 2021-02-11 | 2021-02-11 | 133 | 77d | 0d | 271.68 |
| 136 | 1.5.10.4 | CERROJO DE ALUMINIO DE 6" | 1d | 2021-02-12 | 2021-02-12 | 135 | 77d |  | 456.12 |
| 137 | 1.5.11 | **VIDRIOS, CRISTALES Y SIMILARES** | 1d | 2021-02-11 | 2021-02-11 |  | 78d |  | 30,535.53 |
| 138 | 1.5.11.1 | VENTANA C/CRISTAL TEMPLADO 6 mm INCOLORO | 1d | 2021-02-11 | 2021-02-11 | 129 | 78d |  | 30,535.53 |
| 139 | 1.5.12 | **PINTURA** | 14d | 2021-02-10 | 2021-02-23 |  | 63d |  | 38,092.29 |
| 140 | 1.5.12.1 | PINTURA VINILICA EN MUROS INTERIORES 2 MANOS | 7d | 2021-02-10 | 2021-02-16 | 126 | 63d | 0d | 6,584.6 |
| 141 | 1.5.12.2 | PINTURA VINILICA EN MUROS EXTERIORES 2 MANOS | 7d | 2021-02-10 | 2021-02-16 | 126 | 66d | 0d | 10,837.19 |
| 142 | 1.5.12.3 | PINTURA VINILICA EN COLUMNAS | 7d | 2021-02-17 | 2021-02-23 | 141 | 66d | 0d | 4,131.58 |
| 143 | 1.5.12.4 | PINTURA VINILICA EN COLUMNAS DE AMARRE | 7d | 2021-02-17 | 2021-02-23 | 141 | 66d |  | 1,198.45 |
| 144 | 1.5.12.5 | PINTURA VINILICA EN VIGAS | 7d | 2021-02-17 | 2021-02-23 | 142SS | 66d |  | 4,497.16 |
| 145 | 1.5.12.6 | PINTURA VINILICA EN VIGAS DE AMARRE | 7d | 2021-02-17 | 2021-02-23 | 142SS | 66d |  | 889.4 |
| 146 | 1.5.12.7 | PINTURA VINILICA EN DERRAMES | 7d | 2021-02-17 | 2021-02-23 | 140 | 63d | 0d | 571.98 |
| 147 | 1.5.12.8 | PINTURA VNILICA EN CIELO RASO 2. MANOS | 7d | 2021-02-17 | 2021-02-23 | 140 | 66d |  | 5,864.51 |
| 148 | 1.5.12.9 | PINTURA EN PUERTAS C/ BARNIZ 2 MANOS | 1d | 2021-02-17 | 2021-02-17 | 141 | 72d |  | 3,517.42 |
| 149 | 1.5.13 | **VARIOS** | 10d | 2021-02-17 | 2021-02-26 |  | 63d |  | 10,176.05 |
| 150 | 1.5.13.1 | GRASS SINTERICO | 3d | 2021-02-24 | 2021-02-26 | 146 | 63d |  | 3,931.25 |
| 151 | 1.5.13.2 | PIZARRAS ACRILICA+ TIZERO DE MADERA | 1d | 2021-02-17 | 2021-02-17 | 141 | 72d |  | 4,500 |
| 152 | 1.5.13.3 | ACCESORIOS PARA PSICOMOTRICIDAD | 1d | 2021-02-17 | 2021-02-17 | 141 | 72d |  | 1,744.8 |

| ID | WBS | Task | Duration | Start | Finish | Predecessors | Total slack | Free slack | Cost |
| --- | --- | --- | --- | --- | --- | --- | --- | --- | --- |
| 153 | 1.5.14 | **EVACUACION Y SEÑALIZACION** | 119d | 2020-11-03 | 2021-03-01 |  | 60d |  | 5,525.91 |
| 154 | 1.5.14.1 | SEÑALIZACION GENERAL | 119d | 2020-11-03 | 2021-03-01 | 4 | 60d | 0d | 976.2 |
| 155 | 1.5.14.2 | PINTURA DE TRAFICO, SEGURIDAD EXTERNA | 119d | 2020-11-03 | 2021-03-01 | 154SS | 60d |  | 2,128.58 |
| 156 | 1.5.14.3 | SUMINISTRO E INSTALACION DE EXTINTORES Y GABINETES (04 ABC 6kg, 01 "K" de 6 litros) | 119d | 2020-11-03 | 2021-03-01 | 154SS | 60d |  | 2,421.13 |
| 157 | 1.6 | **INSTALACIONES SANITARIAS** | 80d | 2020-11-22 | 2021-02-09 |  | 80d |  | 81,867.17 |
| 158 | 1.6.1 | **APARATOS Y ACCESORIOS SANITARIOS** | 2d | 2021-01-22 | 2021-01-23 |  | 97d |  | 5,703.02 |
| 159 | 1.6.1.1 | INODORO TANQUE BAJO BLANCO | 1d | 2021-01-22 | 2021-01-22 | 174 | 97d | 0d | 2,852.78 |
| 160 | 1.6.1.2 | LAVATORIO TIPO OVALIN P/EMPOTR. BLANCO | 1d | 2021-01-22 | 2021-01-22 | 159SS | 98d |  | 2,022.3 |
| 161 | 1.6.1.3 | KIT DE ACCESORIOS PARA BAÑO | 1d | 2021-01-22 | 2021-01-22 | 159SS | 97d | 0d | 454.3 |
| 162 | 1.6.1.4 | LAVADERO DE ACERO INOXIDABLE | 1d | 2021-01-23 | 2021-01-23 | 161 | 97d |  | 373.64 |
| 163 | 1.6.2 | **SISTEMA DE AGUA FRIA** | 61d | 2020-11-22 | 2021-01-21 |  | 99d |  | 22,037.92 |
| 164 | 1.6.2.1 | **OBRAS PROVISIONALES** | 10d | 2020-11-22 | 2020-12-01 |  | 149d |  | 235.76 |
| 165 | 1.6.2.1.1 | TRAZO Y REPLANTEO DURANTE LA OBRA | 10d | 2020-11-22 | 2020-12-01 | 12SS+10d | 149d | 0d | 235.76 |
| 166 | 1.6.2.2 | **MOVIMIENTO DE TIERRAS** | 25d | 2020-12-15 | 2021-01-08 |  | 92d |  | 12,528.3 |
| 167 | 1.6.2.2.1 | EXCAVACION MANUAL EN ZANJA EN T.N. A=0.40 mts - Hmax=0.80 | 5d | 2020-12-15 | 2020-12-19 | 42FS+10d | 92d | 0d | 5,643.46 |
| 168 | 1.6.2.2.2 | REFINE Y NIVELACION DE ZANJAS | 1d | 2020-12-20 | 2020-12-20 | 167 | 94d | 0d | 620.04 |
| 169 | 1.6.2.2.3 | CAMA DE ARENA MANUAL E=0.10 m - A=0.40 m | 2d | 2020-12-21 | 2020-12-22 | 168 | 94d | 0d | 4,494.34 |
| 170 | 1.6.2.2.4 | RELLENO DE ZANJA A=0.40 mts - Hmax=0.80 | 7d | 2021-01-02 | 2021-01-08 | 183 | 94d | 0d | 1,466.56 |
| 171 | 1.6.2.2.5 | ACARREO DE MATERIAL EXCEDENTE | 9d | 2020-12-20 | 2020-12-28 | 167 | 115d | 0d | 159.19 |
| 172 | 1.6.2.2.6 | ELIMINACION DE MATERIAL EXCEDENTE CON EQUIPO HASTA 15 km | 1d | 2020-12-29 | 2020-12-29 | 171 | 122d | 0d | 144.71 |
| 173 | 1.6.2.3 | **SUMINISTRO E INSTALACION DE TUBERIA** | 30d | 2020-12-23 | 2021-01-21 |  | 94d |  | 9,273.86 |
| 174 | 1.6.2.3.1 | SALIDA DE AGUA FRIA CON TUBERIA DE PVC-SAP 1/2" | 6d | 2021-01-16 | 2021-01-21 | 170FS+7d | 97d | 0d | 1,276.74 |
| 175 | 1.6.2.3.2 | RED DE DISTRIBUCION TUBERIA DE 1/2"PVC-SAP | 3d | 2020-12-23 | 2020-12-25 | 169 | 94d | 0d | 2,160.89 |
| 176 | 1.6.2.3.3 | RED DE DISTRIBUCION TUBERIA DE 3/4"PVC-SAP | 5d | 2020-12-26 | 2020-12-30 | 175 | 94d | 0d | 1,354.79 |
| 177 | 1.6.2.3.4 | SUMIN. E INST. DE ACCESORIOS DE RED DE AGUA FRIA | 5d | 2020-12-23 | 2020-12-27 | 175SS | 124d |  | 12.46 |
| 178 | 1.6.2.3.5 | VALVULA COMPUERTA DE BRONCE DE UNION ROSCADA DE 1/2" | 2d | 2020-12-26 | 2020-12-27 | 175 | 124d |  | 1,049.62 |
| 179 | 1.6.2.3.6 | VALVULA COMPUERTA DE BRONCE DE UNION ROSCADA DE 3/4" | 3d | 2020-12-31 | 2021-01-02 | 176 | 105d | 0d | 84.5 |
| 180 | 1.6.2.3.7 | CAJA DE MADERA PARA VALVULA COMPUERTA EN PARED | 1d | 2021-01-14 | 2021-01-14 | 182 | 105d | 0d | 1,052.46 |
| 181 | 1.6.2.3.8 | CAJA PARA VALVULA COMPUERTA EN PISO | 1d | 2021-01-15 | 2021-01-15 | 180 | 105d |  | 595.95 |
| 182 | 1.6.2.3.9 | GRIFO DE RIEGO 1/2" | 1d | 2021-01-13 | 2021-01-13 | 179FS+10d | 105d | 0d | 708 |
| 183 | 1.6.2.3.10 | PRUEBA HIDRAULICA + DESINFECCION TUBERIA | 1d | 2021-01-01 | 2021-01-01 | 176FS+1d | 94d | 0d | 978.45 |

| ID | WBS | Task | Duration | Start | Finish | Predecessors | Total slack | Free slack | Cost |
| --- | --- | --- | --- | --- | --- | --- | --- | --- | --- |
| 184 | 1.6.3 | **SISTEMA DE DESAGUE** | 38d | 2020-12-02 | 2021-01-08 |  | 112d |  | 20,341.47 |
| 185 | 1.6.3.1 | **OBRAS PROVISIONALES** | 1d | 2020-12-02 | 2020-12-02 |  | 149d |  | 160.85 |
| 186 | 1.6.3.1.1 | TRAZO Y REPLANTEO DURANTE LA OBRA | 1d | 2020-12-02 | 2020-12-02 | 165 | 149d |  | 160.85 |
| 187 | 1.6.3.2 | **MOVIMIENTO DE TIERRAS** | 25d | 2020-12-15 | 2021-01-08 |  | 112d |  | 8,547.23 |
| 188 | 1.6.3.2.1 | EXCAVACION MANUAL EN ZANJA EN T.N. A=0.40 mts - Hmax=0.80 | 5d | 2020-12-15 | 2020-12-19 | 167SS | 121d | 0d | 3,850.16 |
| 189 | 1.6.3.2.2 | REFINE Y NIVELACION DE ZANJAS | 1d | 2020-12-20 | 2020-12-20 | 168SS | 131d |  | 423.01 |
| 190 | 1.6.3.2.3 | CAMA DE ARENA MANUAL E=0.10 m - A=0.40 m | 2d | 2020-12-21 | 2020-12-22 | 169SS | 113d | 0d | 3,066.2 |
| 191 | 1.6.3.2.4 | RELLENO DE ZANJA A=0.40 mts - Hmax=0.80 | 7d | 2021-01-02 | 2021-01-08 | 170SS | 101d | 0d | 1,000.54 |
| 192 | 1.6.3.2.5 | ACARREO DE MATERIAL EXCEDENTE | 9d | 2020-12-20 | 2020-12-28 | 171SS | 115d | 0d | 108.6 |
| 193 | 1.6.3.2.6 | ELIMINACION DE MATERIAL EXCEDENTE CON EQUIPO HASTA 15 km | 1d | 2020-12-29 | 2020-12-29 | 172SS | 122d |  | 98.72 |
| 194 | 1.6.3.3 | **SUMINISTRO E INSTALACION DE TUBERIA** | 16d | 2020-12-23 | 2021-01-07 |  | 113d |  | 11,633.39 |
| 195 | 1.6.3.3.1 | SALIDA P/DESAGUE EN PVC DE 2" | 4d | 2020-12-25 | 2020-12-28 | 196 | 113d | 0d | 983.62 |
| 196 | 1.6.3.3.2 | SALIDA P/DESAGUE EN PVC DE 4" | 2d | 2020-12-23 | 2020-12-24 | 190 | 113d | 0d | 676.13 |
| 197 | 1.6.3.3.3 | SUMIN. E INST. DE ACCESORIOS DE RED DE DESAGUE | 4d | 2020-12-29 | 2021-01-01 | 195 | 119d |  | 12.59 |
| 198 | 1.6.3.3.4 | SALIDA P/VENTILACION DE 2"PVC | 2d | 2020-12-29 | 2020-12-30 | 195 | 121d |  | 89.42 |
| 199 | 1.6.3.3.5 | RED DE DESAGUE TUBERIA PVC SAL 2" | 2d | 2020-12-23 | 2020-12-24 | 190 | 116d | 0d | 982.19 |
| 200 | 1.6.3.3.6 | RED DE DESAGUE TUBERIA PVC SAL 4" | 4d | 2020-12-25 | 2020-12-28 | 199 | 116d | 0d | 3,030.3 |
| 201 | 1.6.3.3.7 | SUMIDERO DE BRONCE DE 2" | 2d | 2021-01-05 | 2021-01-06 | 195FS+7d | 113d | 0d | 390.95 |
| 202 | 1.6.3.3.8 | REGISTRO DE BRONCE ROSCADO DE PISO 4" | 1d | 2021-01-07 | 2021-01-07 | 201 | 113d |  | 354.48 |
| 203 | 1.6.3.3.9 | CAJA DE REGISTRO DE 12"X 24" | 7d | 2020-12-29 | 2021-01-04 | 200 | 116d |  | 5,113.71 |
| 204 | 1.6.4 | **SISTEMA DE DRENAJE PLUVIAL** | 28d | 2021-01-13 | 2021-02-09 |  | 80d |  | 8,119.75 |
| 205 | 1.6.4.1 | MONTAJE PARA AGUAS DE LLUVIA PVC SAP 3"CLASE 10 | 1d | 2021-02-04 | 2021-02-04 | 112SS | 80d | 0d | 1,892.1 |
| 206 | 1.6.4.2 | TUBERIA PVC SAP D=3"EN LOSA P/EVAC. PLUVIAL | 1d | 2021-02-05 | 2021-02-05 | 205 | 80d | 0d | 1,051.13 |
| 207 | 1.6.4.3 | TUBERIA PVC SAP D=4"ENTERRADA P/EVAC. PLUVIAL | 1d | 2021-02-06 | 2021-02-06 | 206 | 80d | 0d | 1,090.52 |
| 208 | 1.6.4.4 | SUMIN. E INST. DE ACCESORIOS | 1d | 2021-02-07 | 2021-02-07 | 207 | 82d |  | 12.59 |
| 209 | 1.6.4.5 | SUMIDERO CON REJILLA DE 3" | 1d | 2021-01-13 | 2021-01-13 | 215 | 101d | 0d | 472.08 |
| 210 | 1.6.4.6 | CANALETA DE FIERRO GALVANIZADO P/EVAC. PLUVIAL | 2d | 2021-02-07 | 2021-02-08 | 207 | 80d | 0d | 575.39 |
| 211 | 1.6.4.7 | REJILLA PARA CANAL DE EVACUACION | 2d | 2021-02-08 | 2021-02-09 | 210SS+1d | 80d |  | 3,025.94 |

| ID | WBS | Task | Duration | Start | Finish | Predecessors | Total slack | Free slack | Cost |
| --- | --- | --- | --- | --- | --- | --- | --- | --- | --- |
| 212 | 1.6.5 | **TANQUE DE ELEVADO Y CISTERNA** | 59d | 2020-11-22 | 2021-01-19 |  | 101d |  | 25,665.01 |
| 213 | 1.6.5.1 | **OBRAS PROVISIONALES** | 7d | 2020-11-22 | 2020-11-28 |  | 153d |  | 4.96 |
| 214 | 1.6.5.1.1 | TRAZO Y REPLANTEO DURANTE LA OBRA | 7d | 2020-11-22 | 2020-11-28 | 165SS | 153d |  | 4.96 |
| 215 | 1.6.5.2 | **MOVIMIENTO DE TIERRAS** | 24d | 2020-12-20 | 2021-01-12 |  | 101d | 0d | 97.92 |
| 216 | 1.6.5.2.1 | EXCAVACION P/CIMIENTOS, ZAPATAS Y VIGAS DE CIMENTACION | 4d | 2020-12-20 | 2020-12-23 | 188 | 121d |  | 73.57 |
| 217 | 1.6.5.2.2 | RELLENO COMPACTADO CON MATERIAL PROPIO | 4d | 2021-01-09 | 2021-01-12 | 191 | 101d |  | 10.27 |
| 218 | 1.6.5.2.3 | ACARREO DE MATERIAL EXCEDENTE | 1d | 2020-12-29 | 2020-12-29 | 192 | 115d |  | 14.08 |
| 219 | 1.6.5.3 | **CONCRETO ARMADO** | 48d | 2020-11-27 | 2021-01-13 |  | 107d |  | 9,461.43 |
| 220 | 1.6.5.3.1 | **ZAPATAS** | 18d | 2020-11-27 | 2020-12-14 |  | 137d |  | 428.58 |
| 221 | 1.6.5.3.1.1 | CONCRETO F'C= 175 KG/CM2 - ZAPATAS | 7d | 2020-12-08 | 2020-12-14 | 60SS | 137d |  | 336.7 |
| 222 | 1.6.5.3.1.2 | ACERO DE REFUERZO FY= 4200 KG/CM2 - ZAPATAS | 9d | 2020-11-27 | 2020-12-05 | 61SS | 146d |  | 91.88 |
| 223 | 1.6.5.3.2 | **COLUMNAS** | 23d | 2020-12-14 | 2021-01-05 |  | 115d |  | 7,681.69 |
| 224 | 1.6.5.3.2.1 | CONCRETO F'C= 175 KG/CM2 - COLUMNAS | 1d | 2021-01-05 | 2021-01-05 | 67SS | 115d |  | 2,402 |
| 225 | 1.6.5.3.2.2 | ENCOFRADO Y DESENCOFRADO NORMAL - COLUMNAS | 12d | 2020-12-24 | 2021-01-04 | 68SS | 116d |  | 2,505.21 |
| 226 | 1.6.5.3.2.3 | ACERO DE REFUERZO FY= 4200 KG/CM2 - COLUMNAS | 10d | 2020-12-14 | 2020-12-23 | 69SS | 128d |  | 2,774.48 |
| 227 | 1.6.5.3.3 | **VIGAS** | 19d | 2020-12-26 | 2021-01-13 |  | 107d |  | 392.6 |
| 228 | 1.6.5.3.3.1 | CONCRETO F'C= 175 KG/CM2 - VIGAS | 1d | 2021-01-13 | 2021-01-13 | 75SS | 107d |  | 81.58 |
| 229 | 1.6.5.3.3.2 | ENCOFRADO Y DESENCOFRADO NORMAL - VIGAS | 10d | 2021-01-03 | 2021-01-12 | 76SS | 108d |  | 108.12 |
| 230 | 1.6.5.3.3.3 | ACERO DE REFUERZO FY= 4200 KG/CM2 - VIGAS | 7d | 2020-12-26 | 2021-01-01 | 77SS | 119d |  | 202.9 |
| 231 | 1.6.5.3.4 | **LOSA** | 6d | 2021-01-08 | 2021-01-13 |  | 107d |  | 958.56 |
| 232 | 1.6.5.3.4.1 | CONCRETO F'C= 175 KG/CM2 - LOSA | 1d | 2021-01-13 | 2021-01-13 | 83SS | 107d |  | 399.03 |
| 233 | 1.6.5.3.4.2 | ENCOFRADO Y DESENCOFRADO NORMAL - LOSA | 4d | 2021-01-08 | 2021-01-11 | 84SS | 107d | 0d | 409.8 |
| 234 | 1.6.5.3.4.3 | ACERO DE REFUERZO FY= 4200 KG/CM2 - LOSA | 1d | 2021-01-12 | 2021-01-12 | 86SS | 108d |  | 149.73 |
| 235 | 1.6.5.4 | **SUMINISTRO E INSTALACION DE TANQUE ELEVADO Y CISTERNA** | 2d | 2021-01-12 | 2021-01-13 |  | 107d |  | 4,844.49 |
| 236 | 1.6.5.4.1 | SUM. E INST. DE TANQUE ELEVADO Y CISTERNA | 2d | 2021-01-12 | 2021-01-13 | 233 | 107d |  | 4,844.49 |

| ID | WBS | Task | Duration | Start | Finish | Predecessors | Total slack | Free slack | Cost |
| --- | --- | --- | --- | --- | --- | --- | --- | --- | --- |
| 237 | 1.6.5.5 | **SUMINISTRO E INSTALACION DE TUBERIA** | 7d | 2021-01-13 | 2021-01-19 |  | 101d |  | 11,256.21 |
| 238 | 1.6.5.5.1 | SUM. E INST. DE LINEA DE IMPULSION Ø1/2", INCLUYE VALVULAS Y ACCESORIOS | 1d | 2021-01-13 | 2021-01-13 | 209SS | 101d | 0d | 254.76 |
| 239 | 1.6.5.5.2 | SUM. E INST. DE LINEA DE ALIMENTACION Ø3/4", INCLUYE VALVULAS Y ACCESORIOS | 1d | 2021-01-14 | 2021-01-14 | 238 | 101d | 0d | 255.74 |
| 240 | 1.6.5.5.3 | TUBERIA PVC D=1/2". C-10 | 2d | 2021-01-14 | 2021-01-15 | 238 | 105d |  | 4,641.31 |
| 241 | 1.6.5.5.4 | TUBERIA PVC D=3/4". C-10 | 2d | 2021-01-15 | 2021-01-16 | 239 | 101d | 0d | 3,400.83 |
| 242 | 1.6.5.5.5 | TUBERIA PVC SAP D=2", C-10 | 2d | 2021-01-17 | 2021-01-18 | 241 | 101d | 0d | 2,643.21 |
| 243 | 1.6.5.5.6 | PRUEBA HIDRAULICA + DESINFECCION TUBERIA | 1d | 2021-01-19 | 2021-01-19 | 242 | 101d |  | 60.36 |
| 244 | 1.7 | **SALIDAS ELECTRICAS** | 88d | 2020-11-02 | 2021-01-28 |  | 92d |  | 71,381.89 |
| 245 | 1.7.1 | **INSTALACIONES ELECTRICAS** | 11d | 2021-01-06 | 2021-01-16 |  | 98d |  | 14,817.57 |
| 246 | 1.7.1.1 | SALIDA PARA CENTRO DE LUZ P/EQ. ADOSADO | 6d | 2021-01-06 | 2021-01-11 | 297FS-2d | 98d | 0d | 4,606.55 |
| 247 | 1.7.1.2 | SALIDA PARA LUMINARIA DE EMERGENCIA | 6d | 2021-01-06 | 2021-01-11 | 246SS | 109d |  | 1,204.79 |
| 248 | 1.7.1.3 | SALIDA PARA TOMACORRIENTE DOBLE | 4d | 2021-01-08 | 2021-01-11 | 251FS-2d | 98d | 0d | 2,294.05 |
| 249 | 1.7.1.4 | SALIDA PARA TOMACORRIENTE A PRUEBA DE AGUA | 1d | 2021-01-12 | 2021-01-12 | 248 | 98d | 0d | 260.58 |
| 250 | 1.7.1.5 | SALIDA PARA TOMACORRIENTE LUZ DE EMERGENCIA | 1d | 2021-01-13 | 2021-01-13 | 249 | 107d |  | 978.34 |
| 251 | 1.7.1.6 | SALIDA PARA INTERRUPTOR | 1d | 2021-01-09 | 2021-01-09 | 255 | 98d | 0d | 1,184.4 |
| 252 | 1.7.1.7 | SALIDA PARA TOMA DATOS - INTERNET | 1d | 2021-01-14 | 2021-01-14 | 254 | 98d | 0d | 151.44 |
| 253 | 1.7.1.8 | SALIDA PARA VIDEO VIGILANCIA | 2d | 2021-01-15 | 2021-01-16 | 252 | 98d | 0d | 1,247.4 |
| 254 | 1.7.1.9 | SALIDA PARA TELEFONO | 1d | 2021-01-13 | 2021-01-13 | 249 | 98d | 0d | 112.49 |
| 255 | 1.7.1.10 | SALIDA PARA BRAQUETE | 3d | 2021-01-06 | 2021-01-08 | 246SS | 98d | 0d | 2,215.08 |
| 256 | 1.7.1.11 | SALIDA PARA PARLANTES | 2d | 2021-01-15 | 2021-01-16 | 252 | 104d |  | 562.45 |
| 257 | 1.7.2 | **CANALIZACION, CONDUCTOS O TUBERIAS** | 7d | 2021-01-08 | 2021-01-14 |  | 92d |  | 4,147.46 |
| 258 | 1.7.2.1 | CABLEADO P/SALIDA DE CENTRO DE LUZ P/EQ. ADOSADO | 1d | 2021-01-08 | 2021-01-08 | 297 | 92d | 0d | 822.9 |
| 259 | 1.7.2.2 | CABLEADO P/SALIDA DE EQ. ILUMINACION DE EMERGENCIA | 1d | 2021-01-09 | 2021-01-09 | 258 | 92d | 0d | 215.22 |
| 260 | 1.7.2.3 | CABLEADO P/SALIDA DE TOMACORRIENTE DOBLE | 1d | 2021-01-10 | 2021-01-10 | 259 | 92d | 0d | 726.7 |
| 261 | 1.7.2.4 | CABLEADO P/SALIDA DE TOMACORRIENTE A PRUEBA DE AGUA | 1d | 2021-01-11 | 2021-01-11 | 260 | 92d | 0d | 81.63 |
| 262 | 1.7.2.5 | CABLEADO P/SALIDA DE TOMACORRIENTE LUZ DE EMERGENCIA | 1d | 2021-01-12 | 2021-01-12 | 261 | 108d |  | 169.95 |
| 263 | 1.7.2.6 | CABLEADO P/SALIDA DE INTERRUPTOR SIMPLE | 1d | 2021-01-10 | 2021-01-10 | 259 | 107d | 0d | 309.4 |
| 264 | 1.7.2.7 | CABLEADO P/SALIDA DE INTERRUPTOR DOBLE | 1d | 2021-01-11 | 2021-01-11 | 263 | 107d | 0d | 109.2 |
| 265 | 1.7.2.8 | CABLEADO P/SALIDA DE INTERRUPTOR CONMUTACION SIMPLE | 1d | 2021-01-12 | 2021-01-12 | 264 | 107d | 0d | 285.24 |
| 266 | 1.7.2.9 | CABLEADO P/SALIDA DE VOZ Y DATA | 1d | 2021-01-12 | 2021-01-12 | 261 | 92d | 0d | 98.34 |
| 267 | 1.7.2.10 | CABLEADO PARA VIDEO VIGILANCIA | 1d | 2021-01-13 | 2021-01-13 | 266 | 92d | 0d | 729.12 |
| 268 | 1.7.2.11 | CABLEADO PARA SALIDA DE TELEFONO | 1d | 2021-01-11 | 2021-01-11 | 263 | 108d | 0d | 22.2 |
| 269 | 1.7.2.12 | CABLEADO PARA SALIDA DE BRAQUETE | 1d | 2021-01-09 | 2021-01-09 | 258 | 111d |  | 455.76 |
| 270 | 1.7.2.13 | CABLEADO P/SALIDA DE PARLANTE | 1d | 2021-01-14 | 2021-01-14 | 267 | 92d | 0d | 121.8 |

| ID | WBS | Task | Duration | Start | Finish | Predecessors | Total slack | Free slack | Cost |
| --- | --- | --- | --- | --- | --- | --- | --- | --- | --- |
| 271 | 1.7.3 | **ARTEFACTOS** | 14d | 2021-01-15 | 2021-01-28 |  | 92d |  | 23,037.19 |
| 272 | 1.7.3.1 | SUM. E INSTAL. EQUIPO KIT-S OFFISIMPLE TIPO REJILLA ADOSABLE 236/865 EBC - 2X36 W | 2d | 2021-01-15 | 2021-01-16 | 270 | 92d | 0d | 11,498 |
| 273 | 1.7.3.2 | SUM. E INSTAL. LUM INT DWNLIGHT EASY SURFACE ADOSADO TECHO LED 15.5 W 4000K IP20 BLANCO CIRCULAR TC-0162-BLA | 1d | 2021-01-17 | 2021-01-17 | 272 | 92d | 0d | 1,569.75 |
| 274 | 1.7.3.3 | SUM. E INSTAL. EQUIPO BRAQUETTE | 1d | 2021-01-18 | 2021-01-18 | 273 | 92d | 0d | 3,767.4 |
| 275 | 1.7.3.4 | SUM. E INSTAL. EQUIPO SPOT EMPOTRADO | 2d | 2021-01-19 | 2021-01-20 | 274 | 92d | 0d | 143.52 |
| 276 | 1.7.3.5 | SUM. E INSTAL. LUMINARIA DE EMERGENCIA ADOSADA A LA PARED | 1d | 2021-01-21 | 2021-01-21 | 275 | 92d | 0d | 911.24 |
| 277 | 1.7.3.6 | SUM. E INSTAL. LUMINARIA DE EMERGENCIA ADOSADA A TECHO | 2d | 2021-01-22 | 2021-01-23 | 276 | 92d | 0d | 312.24 |
| 278 | 1.7.3.7 | CENTRAL DE VIDEO VIGILANCIA | 1d | 2021-01-24 | 2021-01-24 | 277 | 92d | 0d | 814.62 |
| 279 | 1.7.3.8 | CAMARA DE VIDEO VIGILANCIA | 2d | 2021-01-25 | 2021-01-26 | 278 | 92d | 0d | 2,197.32 |
| 280 | 1.7.3.9 | SUM. E INSTAL. PARLANTES AMBIENTALES | 2d | 2021-01-27 | 2021-01-28 | 279 | 92d |  | 1,823.1 |
| 281 | 1.7.4 | **ACCESORIOS** | 3d | 2021-01-11 | 2021-01-13 |  | 107d |  | 1,981.15 |
| 282 | 1.7.4.1 | TOMACORRIENTE DOBLE C/TOMA A TIERRA | 1d | 2021-01-12 | 2021-01-12 | 248 | 108d |  | 1,194.11 |
| 283 | 1.7.4.2 | TOMACORRIENTE DOBLE C/TOMA A TIERRA A PRUEBA DE AGUA | 1d | 2021-01-12 | 2021-01-12 | 261 | 108d |  | 85.71 |
| 284 | 1.7.4.3 | INTERRUPTOR SIMPLE UNIPOLAR 10 A | 1d | 2021-01-11 | 2021-01-11 | 263 | 109d |  | 334.39 |
| 285 | 1.7.4.4 | INTERRUPTOR DOBLE 10 A | 1d | 2021-01-12 | 2021-01-12 | 264 | 108d |  | 111.36 |
| 286 | 1.7.4.5 | INTERRUPTOR CONMUTACION UNIPOLAR SIMPLE 10 A | 1d | 2021-01-13 | 2021-01-13 | 265 | 107d |  | 169.08 |
| 287 | 1.7.4.6 | PLACA TOMA DATOS - INTERNET | 1d | 2021-01-13 | 2021-01-13 | 266 | 107d |  | 58.08 |
| 288 | 1.7.4.7 | PLACA DE TELEFONO DIRECTO | 1d | 2021-01-12 | 2021-01-12 | 268 | 108d |  | 28.42 |
| 289 | 1.7.5 | **CAJAS** | 1d | 2021-01-17 | 2021-01-17 |  | 98d |  | 705.84 |
| 290 | 1.7.5.1 | CAJAS DE PASO OCTOGONAL | 1d | 2021-01-17 | 2021-01-17 | 253 | 98d | 0d | 705.84 |
| 291 | 1.7.6 | **TABLEROS GENERAL Y DE DISTRIBUCION** | 4d | 2021-01-18 | 2021-01-21 |  | 98d |  | 3,579.12 |
| 292 | 1.7.6.1 | TABLERO GENERAL TG 24 POLOS | 1d | 2021-01-18 | 2021-01-18 | 290 | 98d | 0d | 1,857.18 |
| 293 | 1.7.6.2 | TABLERO DE DISTRIBUCION TD-1, 18 POLOS | 1d | 2021-01-19 | 2021-01-19 | 292 | 98d | 0d | 643.85 |
| 294 | 1.7.6.3 | TABLERO DE DISTRIBUCION TD-2, 18 POLOS | 1d | 2021-01-20 | 2021-01-20 | 293 | 98d | 0d | 643.85 |
| 295 | 1.7.6.4 | TABLERO DE DISTRIBUCION TD-B BOMBA | 1d | 2021-01-21 | 2021-01-21 | 294 | 98d | 0d | 434.24 |

| ID | WBS | Task | Duration | Start | Finish | Predecessors | Total slack | Free slack | Cost |
| --- | --- | --- | --- | --- | --- | --- | --- | --- | --- |
| 296 | 1.7.7 | **EXCAVACION PARA INSTALACIÓN DE CONDUCTOR** | 24d | 2021-01-03 | 2021-01-26 |  | 92d |  | 1,997.29 |
| 297 | 1.7.7.1 | EXCAVACION PARA CABLE SUBTERRANEO H=1.00m. | 5d | 2021-01-03 | 2021-01-07 | 167FS+14d | 92d | 0d | 1,610.29 |
| 298 | 1.7.7.2 | RELLENO CON MATERIAL PROPIO | 4d | 2021-01-08 | 2021-01-11 | 170FS-1d | 94d | 0d | 289.78 |
| 299 | 1.7.7.3 | RELLENO COMPACTADO CON MATERIAL DE PRESTAMO | 1d | 2021-01-12 | 2021-01-12 | 298 | 94d | 0d | 23.05 |
| 300 | 1.7.7.4 | ACARREO DE MATERIAL EXCEDENTE D= 30M | 8d | 2021-01-13 | 2021-01-20 | 299 | 94d | 0d | 35.86 |
| 301 | 1.7.7.5 | ELIMINACION DE MATERIAL EXCEDENTE | 6d | 2021-01-21 | 2021-01-26 | 300 | 94d |  | 38.31 |
| 302 | 1.7.8 | **INSTALACION DEL SISTEMA PUESTA A TIERRA** | 3d | 2020-11-02 | 2020-11-04 |  | 177d |  | 6,848.85 |
| 303 | 1.7.8.1 | SUMINISTRO E INSTAL. DE PUESTA A TIERRA | 1d | 2020-11-03 | 2020-11-03 | 4 | 177d | 0d | 4,835.84 |
| 304 | 1.7.8.2 | PRUEBAS ELECTRICAS PUESTA TIERRA | 1d | 2020-11-04 | 2020-11-04 | 303 | 177d |  | 1,751.64 |
| 305 | 1.7.8.3 | LIMPIEZA FINAL DE OBRA | 1d | 2020-11-02 | 2020-11-02 |  | 179d |  | 261.37 |
| 306 | 1.7.9 | **SISTEMA DE ALARMA CONTRA INCENDIO** | 3d | 2021-01-17 | 2021-01-19 |  | 101d |  | 2,652.44 |
| 307 | 1.7.9.1 | SALIDA PARA SENSORES DE HUMO Y TEMPERATURA | 1d | 2021-01-17 | 2021-01-17 | 253 | 101d | 0d | 609.6 |
| 308 | 1.7.9.2 | SALIDA PARA DISPOSITIVO DE ACCIONAMIENTO MANUAL | 1d | 2021-01-18 | 2021-01-18 | 307 | 101d | 0d | 411.28 |
| 309 | 1.7.9.3 | SALIDA PARA LUZ (SIRENA CONTRA INCENDIO) | 1d | 2021-01-19 | 2021-01-19 | 308 | 101d |  | 251.6 |
| 310 | 1.7.9.4 | DETECTOR DE HUMO DIRECCIONAL EN 54 INCLUYE BASE | 1d | 2021-01-18 | 2021-01-18 | 307 | 101d | 0d | 586.2 |
| 311 | 1.7.9.5 | DISPOSITIVO DE ACCIONAMIENTO MANUAL | 1d | 2021-01-19 | 2021-01-19 | 308 | 101d |  | 257.28 |
| 312 | 1.7.9.6 | LUZ Y PARLANTE ( SIRENA CONTRA INCENDIO) | 1d | 2021-01-19 | 2021-01-19 | 310 | 101d |  | 536.48 |
| 313 | 1.7.10 | **ALIMENTADORES SECUNDARIOS CANALIZACION, CONDUCTOS O TUBERIAS** | 4d | 2021-01-08 | 2021-01-11 |  | 109d |  | 6,794.77 |
| 314 | 1.7.10.1 | SUM. E INSTAL. CABLE 2 x 10 mm2 N2XOH + 1 x 10 mm2 N2XOH (T), 25mm PVC - P | 1d | 2021-01-08 | 2021-01-08 | 319 | 112d |  | 129.48 |
| 315 | 1.7.10.2 | SUM. E INSTAL. CABLE 2 x 6 mm2 N2XOH + 1 x 6 mm2 N2XOH (T), ∅ 25mm PVC - P | 1d | 2021-01-11 | 2021-01-11 | 260 | 109d |  | 3,916.87 |
| 316 | 1.7.10.3 | SUM. E INSTAL. CABLE 2 x 4 mm2 NH-80 + 1 x 4 mm2 NH-80 (T) ø 25 mm PVC - P | 1d | 2021-01-09 | 2021-01-09 | 258 | 110d | 0d | 2,364.86 |
| 317 | 1.7.10.4 | PROTECCION Y SEÑALIZACION DE CABLE SUBTERRANEO | 1d | 2021-01-10 | 2021-01-10 | 316 | 110d |  | 383.56 |
| 318 | 1.7.11 | **BUZONES** | 19d | 2021-01-03 | 2021-01-21 |  | 99d |  | 967.85 |
| 319 | 1.7.11.1 | EXCAVACION PARA BUZON DE CONCRETO (CAJA DE PASO) | 5d | 2021-01-03 | 2021-01-07 | 297SS | 112d | 0d | 21.24 |
| 320 | 1.7.11.2 | ACARREO DE MATERIAL EXCEDENTE D= 30M | 6d | 2021-01-13 | 2021-01-18 | 300SS | 99d | 0d | 1.89 |
| 321 | 1.7.11.3 | BUZON DE CONCRETO (CAJA DE PASO) 0.80x0.80m. | 3d | 2021-01-19 | 2021-01-21 | 320 | 99d |  | 944.72 |

| ID | WBS | Task | Duration | Start | Finish | Predecessors | Total slack | Free slack | Cost |
| --- | --- | --- | --- | --- | --- | --- | --- | --- | --- |
| 322 | 1.7.12 | **SALIDA DE FUERZA** | 1d | 2021-01-22 | 2021-01-22 |  | 98d |  | 668.61 |
| 323 | 1.7.12.1 | SALIDA DE ELECTROBOMBA DE 1 HP | 1d | 2021-01-22 | 2021-01-22 | 295 | 98d |  | 668.61 |
| 324 | 1.7.13 | **OTROS** | 5d | 2021-01-15 | 2021-01-19 |  | 101d |  | 3,183.75 |
| 325 | 1.7.13.1 | SUM. E INSTAL. GABINETE PRINCIPAL DE CENTRAL DE DATA/VOZ | 1d | 2021-01-15 | 2021-01-15 | 252 | 104d | 0d | 838 |
| 326 | 1.7.13.2 | SUM. E INSTAL. GABINETE PRINCIPAL DE TELEFONO | 1d | 2021-01-16 | 2021-01-16 | 325 | 104d |  | 1,145.75 |
| 327 | 1.7.13.3 | SUMINISTRO E INSTALACION DE MEDIDOR DE ENERGIA ELECTRICA (INCLUYE ACCESORIOS) | 1d | 2021-01-19 | 2021-01-19 | 292 | 101d |  | 1,200 |
